# 07-10-22 Trim Coils

Schedule from MS Project, 2007-11-05 to 2009-03-10.
Home

## Calendars

- Standard: Mon-Fri 08:00-12:00, 13:00-17:00; Sat-Sun off.

## Schedule

| ID | Task | Duration | Start | Finish | Predecessors | Total slack | Free slack | Constraint |
| --- | --- | --- | --- | --- | --- | --- | --- | --- |
| 1 | Peer Review of Requirements | 1d | 2007-11-05 | 2007-11-05 |  | 0d |  | start no earlier than 2007-11-05 |
| 2 | Trim Coil System Requirements Document | 10d | 2007-11-06 | 2007-11-19 | 1 | 0d |  |  |
| 3 | Review and Approve SRD | 5d | 2007-11-20 | 2007-11-26 | 2 | 10d |  |  |
| 4 | Complete Trim Coil Magnetics Analysis | 3d | 2007-11-20 | 2007-11-22 | 2 | 2d | 0d |  |
| 5 | Complete Trim Coil Cooling Analysis | 5d | 2007-11-23 | 2007-11-29 | 4 | 2d | 0d |  |
| 6 | Modify PF Coil Structures | 5d | 2007-11-20 | 2007-11-26 | 2 | 0d |  |  |
| 7 | Complete Layout of Trim Coils | 10d | 2007-11-27 | 2007-12-10 | 2, 6 | 0d |  |  |
| 8 | Stress Analysis of Coil and Structure | 5d | 2007-11-30 | 2007-12-06 | 5 | 2d |  |  |
| 9 | Prepare for PDR | 3d | 2007-12-11 | 2007-12-13 | 3, 8, 7 | 0d |  |  |
| 10 | Trim Coil PDR | 1d | 2007-12-14 | 2007-12-14 | 9 | 0d |  |  |
| 11 | Procure Trim Coil Insulation | 50d | 2007-12-17 | 2008-02-22 | 10 | 272d |  |  |
| 12 | Procure Trim Coil Conductor | 100d | 2007-12-26 | 2008-05-13 | 14 | 35d |  |  |
| 13 | Conductor Procurement Spec | 2d | 2007-12-17 | 2007-12-18 | 10 | 18d | 0d |  |
| 14 | Review and Approve Conductor Spec. | 5d | 2007-12-19 | 2007-12-25 | 13 | 35d | 0d |  |
| 15 | Prepare Trim Coil Procurement Spec. | 10d | 2007-12-19 | 2008-01-01 | 13 | 310d |  |  |
| 16 | Approve Procurement Spec | 5d | 2007-12-19 | 2007-12-25 | 13 | 18d |  |  |
| 17 | Complete Trim Coil Detailed Drawings | 15d | 2007-12-17 | 2008-01-04 | 10 | 0d |  |  |
| 18 | Fabricate Trim Coil MockUps | 20d | 2008-01-07 | 2008-02-01 | 17 | 122d | 0d |  |
| 19 | Use Mockup to Spot Bracket Locations | 60d | 2008-02-04 | 2008-04-25 | 18 | 122d | 0d |  |
| 20 | Complete Trim Coil Structure Detail Drawings | 10d | 2008-01-07 | 2008-01-18 | 17 | 0d |  |  |
| 21 | Prepare for FDR | 5d | 2008-01-21 | 2008-01-25 | 20, 16 | 0d |  |  |
| 22 | Trim Coil + Structure FDR | 1d | 2008-01-28 | 2008-01-28 | 21 | 0d |  |  |
| 23 | Resolve Chits | 5d | 2008-01-29 | 2008-02-04 | 22 | 0d |  |  |
| 24 | Trim Coil Procurement | 25d | 2008-02-05 | 2008-03-10 | 23 | 0d |  |  |
| 25 | Place Order For Trim Coil | 1d | 2008-03-11 | 2008-03-11 | 24 | 0d |  |  |
| 26 | Vendor Design and Fixture Fabrication | 80d | 2008-03-12 | 2008-07-01 | 25 | 0d |  |  |
| 27 | Coil Fab of First set of Trim Coils | 45d | 2008-07-02 | 2008-09-02 | 26, 12 | 0d |  |  |
| 28 | Coil Fab Last Trim Coil Complete | 90d | 2008-09-03 | 2009-01-06 | 27 | 0d |  |  |
| 29 | Procure Material for Structure | 40d | 2008-01-29 | 2008-03-24 | 22 | 106d | 0d |  |
| 30 | Fabricate Brackets | 40d | 2008-03-25 | 2008-05-19 | 29 | 106d | 0d |  |
| 31 | Install Brackets on Modular Coils First Field Period | 20d | 2008-05-20 | 2008-06-16 | 30, 19 | 106d | 0d |  |
| 32 | Install Coils On First Field Period | 15d | 2008-09-03 | 2008-09-23 | 31, 27 | 75d |  |  |
| 33 | Install Remaining Brackets | 40d | 2008-06-17 | 2008-08-11 | 31 | 106d |  |  |
| 34 | Install Remaining Coils | 45d | 2009-01-07 | 2009-03-10 | 32, 33, 28 | 0d |  |  |
