# Trim Coil Procurement Timeline

Schedule from MS Project, 2008-05-06 to 2008-06-16.
Home

## Calendars

- Standard: Mon-Fri 08:00-12:00, 13:00-17:00; Sat-Sun off.

## Schedule

| ID | WBS | Task | Duration | Start | Finish | Predecessors | Total slack | Constraint |
| --- | --- | --- | --- | --- | --- | --- | --- | --- |
| 2 | 1 | Trim Coil FDR | 1d | 2008-05-06 | 2008-05-06 |  | 0d | start no earlier than 2008-05-06 |
| 3 | 2 | Resolve Chits and Update Package | 5d | 2008-05-07 | 2008-05-13 | 2 | 0d |  |
| 4 | 3 | Prepare Procurement Package | 3d | 2008-05-14 | 2008-05-16 | 3 | 0d |  |
| 5 | 4 | Vendors Package and Provide Proposals | 10d | 2008-05-19 | 2008-05-30 | 4 | 0d |  |
| 6 | 5 | Bids Due | 1d | 2008-06-02 | 2008-06-02 | 5 | 0d |  |
| 7 | 6 | Evaluate Bids and ask for Clarifications | 4d | 2008-06-03 | 2008-06-06 | 6 | 0d |  |
| 8 | 7 | Best and Final Due | 3d | 2008-06-09 | 2008-06-11 | 7 | 0d |  |
| 9 | 8 | Review Best and Final | 1d | 2008-06-12 | 2008-06-12 | 8 | 0d |  |
| 10 | 9 | Award Sub Contract for Coil | 2d | 2008-06-13 | 2008-06-16 | 9 | 0d |  |
